# Commisionning DCS/ESD System For Binak Gas Station

Schedule from Primavera P6, 2025-02-22 to 2025-09-22, data date 2025-03-16, costs in USD, A marks actual dates.
????? ????? ??????? ???? 1403/11/30 ?? ???? / KOM held / on 1403/12/07 at Payam workshop / PIM held at Hirgan Offcie on / 1403/12/08 / PO Number : / BK-HD-GCS-CO-0031-01

## Calendars

- Ideh Global: Mon-Wed 08:00-12:00, 13:00-17:00; Thu-Fri off; Sat-Sun 08:00-12:00, 13:00-17:00. Exceptions (off unless hours are given): 2025-03-19, 2025-03-22 to 2025-03-26, 2025-03-29 to 2025-04-02, 2025-06-04, 2025-06-14, 2025-07-05 to 2025-07-06, 2025-08-24, 2025-09-01, 2025-09-10.

## Schedule

| ID | WBS | Activity | Type | Duration | Start | Finish | Predecessors | Complete | Remaining | Planned start | Planned finish | Total float | Free float | Cost |
| --- | --- | --- | --- | --- | --- | --- | --- | --- | --- | --- | --- | --- | --- | --- |
|  | Key Mil | **Key Milestone** |  |  | 2025-02-22 | 2025-09-22 |  |  |  |  |  |  |  |  |
| A1590 |  | Start | milestone | 0d | 2025-02-22 A | 2025-02-22 A |  | 100% |  |  |  |  |  |  |
| A1600 |  | P.O | milestone | 0d | 2025-02-22 A | 2025-02-22 A | A1590 SS | 100% |  |  |  |  |  |  |
| A1630 |  | Sending Freezed FEED Documents by Hirgan co (Native File) | milestone | 0d | 2025-02-22 | 2025-02-22 |  |  |  | 2025-03-12 | 2025-03-12 | 135d |  |  |
| A1640 |  | First Payment-Advanced Payment (20% Contract) | milestone | 0d | 2025-02-22 | 2025-02-22 |  |  |  | 2025-03-01 | 2025-03-01 | 2d | 0d |  |
| A1610 |  | KOM-Kick Off Meeting | milestone | 0d | 2025-02-25 A | 2025-02-25 A | A1590 SS, A1600 SS | 100% |  |  |  |  |  |  |
| A1620 |  | PIM-Pre Inspection Meeting | milestone | 0d | 2025-02-26 A | 2025-02-26 A | A1590 SS, A1600 SS, A1610 SS | 100% |  |  |  |  |  |  |
| A1660 |  | Thrid Payment-(20% of Contract) | milestone | 0d | 2025-07-28 | 2025-07-28 | A1720 |  |  |  |  | 38d |  |  |
| A1720 |  | Inspection During Fabrication | milestone | 0d | 2025-07-28 | 2025-07-28 | A1480 FF-15d, A1490 FF-15d, A1500 FF-15d, A1510 FF-15d, A1520 FF-15d, A1530 FF-15d |  |  |  |  | 38d | 0d |  |
| A1650 |  | Second Payment-(10% of Contract) | milestone | 0d | 2025-08-03 | 2025-08-03 | A1710 |  |  |  |  | 33d |  |  |
| A1710 |  | Inspection after Procurement | milestone | 0d | 2025-08-03 | 2025-08-03 | A1350 FF, A1360 FF, A1370 FF, A1380 FF, A1390 FF, A1400 FF, A1410 FF, A1420 FF |  |  |  |  | 33d | 0d |  |
| A1730 |  | Inspection after PreFAT | milestone | 0d | 2025-08-23 | 2025-08-23 | A1540 FF |  |  |  |  | 19d |  |  |
| A1670 |  | Fourth Payment-(40% of Contract) | milestone | 0d | 2025-09-08 | 2025-09-08 | A1550, A1560 FF |  |  |  |  | 9d |  |  |
| A1680 |  | Fifth Payment-(10% of Contract) | milestone | 0d | 2025-09-17 | 2025-09-17 | A1580 |  |  |  |  | 3d |  |  |
| A1740 |  | Finish | milestone | 0d | 2025-09-22 | 2025-09-22 | A1690 FF, A1580 FF |  |  |  |  | 0d |  |  |
|  | Eng | **Engineering (Documentation)** |  |  | 2025-03-08 | 2025-09-14 |  |  |  |  |  |  |  |  |
|  | Hard | **Hardware** |  |  | 2025-03-08 | 2025-09-14 |  |  |  |  |  |  |  |  |
|  | Gen | **General Documents** |  |  | 2025-03-08 | 2025-09-14 |  |  |  |  |  |  |  |  |
| A1000 |  | Vendor Print Index & Schedule (VPIS) |  | 14d | 2025-03-08 A | 2025-04-09 | A1610 SS+10d | 60% | 14d |  |  | 89d | 0d | 0.06 |
| A1030 |  | Inspection & Test Plan (ITP) |  | 28d | 2025-03-08 A | 2025-04-29 | A1000 SS | 60% | 28d |  |  | 97d |  | 0.05 |
| A1035 |  | Packing, Marking And Shipping Procedure |  | 14d | 2025-03-09 A | 2025-04-12 | A1000 SS+1d | 60% | 14d |  |  | 110d |  | 0.05 |
| A1010 |  | Work Breakdown Structure (WBS) |  | 14d | 2025-03-10 A | 2025-04-13 | A1610 SS+12d | 60% | 14d |  |  | 0d |  | 0.05 |
| A1085 |  | Sub Vendor List |  | 14d | 2025-03-15 A | 2025-04-16 | A1010 SS+3d | 60% | 14d |  |  | 0d |  | 0.03 |
| A1020 |  | Time Schedule |  | 14d | 2025-03-17 A | 2025-04-20 | A1010 SS+5d, A1000 SS+5d | 60% | 14d |  |  | 104d |  | 0.05 |
| A1050 |  | Functional Design Specification-DCS/ESD Hardware |  | 28d | 2025-03-18 A | 2025-05-11 | A1000 SS+8d | 60% | 28d |  |  | 89d |  | 0.06 |
| A1060 |  | Functional Design Specification-DCS/ESD Software |  | 28d | 2025-03-18 A | 2025-05-11 | A1000 SS+8d | 60% | 28d |  |  | 89d |  | 0.06 |
| A1070 |  | HMI Graphic Functional Design Specification |  | 28d | 2025-04-05 | 2025-05-12 | A1085 SS+4d |  |  |  |  | 0d |  | 0.06 |
| A1140 |  | Architecture Diagram |  | 28d | 2025-04-08 | 2025-05-17 | A1070 SS+3d |  |  |  |  | 0d |  | 0.06 |
| A1180 |  | Spare part list for commissioning and two years operation |  | 14d | 2025-04-09 | 2025-04-28 | A1070 SS+4d |  |  |  |  | 98d |  | 0.05 |
| A1120 |  | Grounding Plan & Earthing Diagram Principle |  | 28d | 2025-04-16 | 2025-05-25 | A1210 SS+1d |  |  |  |  | 79d |  | 0.04 |
| A1130 |  | DCS/ESD Typical Loop Diagram |  | 14d | 2025-04-20 | 2025-05-07 | A1210 SS, A1260 SS |  |  |  |  | 91d |  | 0.04 |
| A1150 |  | Auxiliary Console & Desk Layout, Arrangement/wiring Diagram |  | 28d | 2025-05-03 | 2025-06-10 | A1270 SS+5d |  |  |  |  | 5d | 0d | 0.06 |
| A1110 |  | Power consumption & Heat Dissipation Calculation |  | 14d | 2025-05-05 | 2025-05-24 | A1150 SS+2d |  |  |  |  | 80d |  | 0.04 |
| A1090 |  | DCS/ESD FAT Procedure |  | 14d | 2025-05-06 | 2025-05-25 | A1150 SS+3d |  |  |  |  | 78d | 0d | 0.06 |
| A1100 |  | DCS/ESD SAT Procedure |  | 14d | 2025-05-07 | 2025-05-26 | A1090 SS+1d |  |  |  |  | 78d |  | 0.06 |
| A1160 |  | HMI Graphic Pages |  | 14d | 2025-06-08 | 2025-06-28 | A1340 |  |  |  |  | 57d |  | 0.04 |
| A1170 |  | Manual/Catalogue |  | 5d | 2025-09-07 | 2025-09-14 | A1550 |  |  |  |  | 6d |  | 0.03 |
| A1190 |  | Packing List |  | 5d | 2025-09-07 | 2025-09-14 | A1550 |  |  |  |  | 6d |  | 0.02 |
| A1200 |  | FAT Report |  | 5d | 2025-09-07 | 2025-09-14 | A1550 |  |  |  |  | 3d | 0d | 0.03 |

Notes:
- A1000: Expenses: (New Expense Item) 0.06
- A1030: Expenses: (New Expense Item) 0.05
- A1035: Expenses: (New Expense Item) 0.05
- A1010: Expenses: (New Expense Item) 0.05
- A1085: Expenses: (New Expense Item) 0.03
- A1020: Expenses: (New Expense Item) 0.05
- A1050: Expenses: (New Expense Item) 0.06
- A1060: Expenses: (New Expense Item) 0.06
- A1070: Expenses: (New Expense Item) 0.06
- A1140: Expenses: (New Expense Item) 0.06
- A1180: Expenses: (New Expense Item) 0.05
- A1120: Expenses: (New Expense Item) 0.04
- A1130: Expenses: (New Expense Item) 0.04
- A1150: Expenses: (New Expense Item) 0.06
- A1110: Expenses: (New Expense Item) 0.04
- A1090: Expenses: (New Expense Item) 0.06
- A1100: Expenses: (New Expense Item) 0.06
- A1160: Expenses: (New Expense Item) 0.04
- A1170: Expenses: (New Expense Item) 0.03
- A1190: Expenses: (New Expense Item) 0.02
- A1200: Expenses: (New Expense Item) 0.03

| ID | WBS | Activity | Duration | Start | Finish | Predecessors | Total float | Free float | Cost |
| --- | --- | --- | --- | --- | --- | --- | --- | --- | --- |
|  | DCS | **DCS Documents** |  | 2025-04-15 | 2025-06-29 |  |  |  |  |
| A1210 |  | DCS IO Allocation | 28d | 2025-04-15 | 2025-05-24 | A1140 SS+5d | 0d |  | 0.23 |
| A1220 |  | DCS Cabinets Layout/wiring Diagram | 28d | 2025-04-23 | 2025-06-01 | A1210 SS+6d | 1d | 0d | 0.23 |
| A1230 |  | DCS Bill of Material/License LIST | 14d | 2025-04-26 | 2025-05-13 | A1220 SS+1d | 87d |  | 0.18 |
| A1240 |  | DCS Loop Diagram Printout | 14d | 2025-06-08 | 2025-06-28 | A1320 | 42d | 0d | 0.18 |
| A1250 |  | DCS Application Software Printout | 14d | 2025-06-09 | 2025-06-29 | A1240 SS+1d | 42d |  | 0.18 |
|  | ESD | **ESD Documents** |  | 2025-04-20 | 2025-06-30 |  |  |  |  |
| A1260 |  | ESD IO Allocation | 28d | 2025-04-20 | 2025-05-27 | A1210 SS+3d | 0d |  | 0.18 |
| A1270 |  | ESD Cabinets Layout/wiring Diagram | 28d | 2025-04-26 | 2025-06-02 | A1260 SS+4d | 0d |  | 0.18 |
| A1280 |  | ESD Bill of Material/LICENS LIST | 14d | 2025-04-27 | 2025-05-14 | A1270 SS+1d | 86d |  | 0.16 |
| A1290 |  | ESD Loop Diagram Printout | 14d | 2025-06-08 | 2025-06-28 | A1330 | 41d | 0d | 0.16 |
| A1300 |  | ESD Application Software Printout | 14d | 2025-06-09 | 2025-06-29 | A1290 SS+1d | 41d | 0d | 0.16 |
| A1310 |  | ESD Modbus Mapping list | 14d | 2025-06-10 | 2025-06-30 | A1300 SS+1d | 41d |  | 0.16 |
|  | Soft | **Software** |  | 2025-05-06 | 2025-06-07 |  |  |  |  |
| A1320 |  | DCS System Logic | 22d | 2025-05-06 | 2025-06-07 | A1150 SS+3d | 41d | 0d | 0.75 |
| A1330 |  | ESD System Logic | 22d | 2025-05-06 | 2025-06-07 | A1320 SS | 41d | 0d | 0.75 |
| A1340 |  | HMI | 22d | 2025-05-06 | 2025-06-07 | A1320 SS, A1330 SS | 57d | 0d | 0.5 |
|  | Pro | **Procurement and Supply Raw Material** |  | 2025-04-06 | 2025-08-03 |  |  |  |  |
|  | DCS Cab | **DCS Cabinets** |  | 2025-04-06 | 2025-07-26 |  |  |  |  |
| A1360 |  | Bulk Mterial (Terminal,Wire,Fan,Fuse…) for DCS Cabinets | 50d | 2025-04-06 | 2025-06-16 | A1640 SS+20d | 27d | 26d | 2.5 |
| A1370 |  | DCS Body of Cabinets | 50d | 2025-04-06 | 2025-06-16 | A1640 SS+20d | 27d | 26d | 2.5 |
| A1350 |  | Main Equipment (Card Module,CPU,Power Supply,Barrier,Relay,…) | 35d | 2025-06-02 | 2025-07-26 | A1640 SS, A1220 | 1d | 0d | 15 |
|  | ESD Cab | **ESD Cabinets** |  | 2025-04-06 | 2025-07-27 |  |  |  |  |
| A1390 |  | ESD Body of Cabinets | 50d | 2025-04-06 | 2025-06-16 | A1640 SS+20d | 27d |  | 2.5 |
| A1400 |  | Bulk Mterial (Terminal,Wire,Fan,Fuse,…) for ESD Cabinets | 50d | 2025-04-06 | 2025-06-16 | A1640 SS+20d | 27d |  | 2.5 |
| A1380 |  | Main Equipment (Card Module,CPU,Power Supply,Barrier,Relay,Logic Solver,…) | 35d | 2025-06-03 | 2025-07-27 | A1640 SS, A1270 | 0d |  | 10 |

Notes:
- A1210: Expenses: (New Expense Item) 0.23
- A1220: Expenses: (New Expense Item) 0.23
- A1230: Expenses: (New Expense Item) 0.18
- A1240: Expenses: (New Expense Item) 0.18
- A1250: Expenses: (New Expense Item) 0.18
- A1260: Expenses: (New Expense Item) 0.18
- A1270: Expenses: (New Expense Item) 0.18
- A1280: Expenses: (New Expense Item) 0.16
- A1290: Expenses: (New Expense Item) 0.16
- A1300: Expenses: (New Expense Item) 0.16
- A1310: Expenses: (New Expense Item) 0.16
- A1320: Expenses: (New Expense Item) 0.75
- A1330: Expenses: (New Expense Item) 0.75
- A1340: Expenses: (New Expense Item) 0.5
- A1360: Expenses: (New Expense Item) 2.5
- A1370: Expenses: (New Expense Item) 2.5
- A1350: Expenses: (New Expense Item) 15
- A1390: Expenses: (New Expense Item) 2.5
- A1400: Expenses: (New Expense Item) 2.5
- A1380: Expenses: (New Expense Item) 10

| ID | WBS | Activity | Duration | Start | Finish | Predecessors | Total float | Free float | Cost |
| --- | --- | --- | --- | --- | --- | --- | --- | --- | --- |
|  | Net Cab | **Network Cabinet and Supervisor** |  | 2025-04-06 | 2025-08-03 |  |  |  |  |
| A1420 |  | Supervisor ( Station and Server,Desk and Furniture,Body of Network Cab,Switch,...) | 50d | 2025-04-06 | 2025-06-16 | A1640 SS+20d | 37d | 32d | 13 |
| A1410 |  | Auxiliary Console For ESD System | 35d | 2025-06-11 | 2025-08-03 | A1640 SS, A1150 | 5d | 0d | 2 |
|  | Fab | **Fabrication and Assemble** |  | 2025-06-18 | 2025-08-17 |  |  |  |  |
|  | DCS Cab | **DCS Cabinets** |  | 2025-06-18 | 2025-08-16 |  |  |  |  |
| A1480 |  | DCS Systen Cabinets | 40d | 2025-06-18 | 2025-08-16 | A1350 FS-25d, A1360 FS-25d, A1370 FS-25d | 1d |  | 7.5 |
| A1490 |  | DCS Marshalling Cabinets | 40d | 2025-06-18 | 2025-08-16 | A1350 FS-25d, A1360 FS-25d, A1370 FS-25d | 1d |  | 5 |
|  | ESD Cab | **ESD Cabinets** |  | 2025-06-21 | 2025-08-17 |  |  |  |  |
| A1500 |  | ESD System Cabinets | 40d | 2025-06-21 | 2025-08-17 | A1380 FS-25d, A1390 FS-25d, A1400 FS-25d | 0d |  | 7.5 |
| A1510 |  | ESD Marshalling Cabinets | 40d | 2025-06-21 | 2025-08-17 | A1380 FS-25d, A1390 FS-25d, A1400 FS-25d | 0d |  | 2.5 |
|  | Net Cab | **Network Cabinets** |  | 2025-07-01 | 2025-08-13 |  |  |  |  |
| A1520 |  | Network Cabinet | 30d | 2025-07-01 | 2025-08-13 |  | 2d |  | 5 |
|  | Desk | **Desk and Auxiliary Console** |  | 2025-06-28 | 2025-08-10 |  |  |  |  |
| A1530 |  | Desk and Auxiliary Console | 30d | 2025-06-28 | 2025-08-10 | A1410 FS-25d, A1420 FS-25d | 5d |  | 2.5 |
|  | Pre | **Pre FAT** |  | 2025-08-18 | 2025-08-23 |  |  |  |  |
| A1540 |  | PreFAT for DCS and ESD System Integrated (Software and Hardware PreFAT) | 4d | 2025-08-18 | 2025-08-23 | A1240 SS+5d, A1250 SS+5d, A1290 SS+5d, A1300 SS+5d, A1310 SS+5d, A1480, A1490, A1500, A1510, A1520, A1530 | 0d |  | 1 |
|  | FAT | **FAT** |  | 2025-08-25 | 2025-09-06 |  |  |  |  |
| A1550 |  | FAT DCS and ESD System Integrated (Software and Hardware FAT) | 8d | 2025-08-25 | 2025-09-06 | A1540 | 0d |  | 10 |
|  | Del | **Packing and Delivery** |  | 2025-09-07 | 2025-09-22 |  |  |  |  |
| A1560 |  | Packing all of Items | 2d | 2025-09-07 | 2025-09-08 | A1550 | 0d |  | 1 |
| A1690 |  | IRN/SRN and Delivery To Sie | 6d | 2025-09-15 | 2025-09-22 | A1560 FS+3d | 0d |  | 1 |
|  | FDB | **SAT and Final Data Book** |  | 2025-09-07 | 2025-09-17 |  |  |  |  |
| A1570 |  | Vendor Final Data Book Index | 2d | 2025-09-07 | 2025-09-08 | A1200 SS, A1550 | 3d | 0d | 0.1 |
| A1580 |  | Final Data Book Preparation | 6d | 2025-09-09 | 2025-09-17 | A1570 | 3d | 0d | 1.9 |

Notes:
- A1420: Expenses: (New Expense Item) 13
- A1410: Expenses: (New Expense Item) 2
- A1480: Expenses: (New Expense Item) 7.5
- A1490: Expenses: (New Expense Item) 5
- A1500: Expenses: (New Expense Item) 7.5
- A1510: Expenses: (New Expense Item) 2.5
- A1520: Expenses: (New Expense Item) 5
- A1530: Expenses: (New Expense Item) 2.5
- A1540: Expenses: (New Expense Item) 1
- A1550: Expenses: (New Expense Item) 10
- A1560: Expenses: (New Expense Item) 1
- A1690: Expenses: (New Expense Item) 1
- A1570: Expenses: (New Expense Item) 0.1
- A1580: Expenses: (New Expense Item) 1.9
